# Suspending Activities using LOE Bars

Schedule from Primavera P6, 2012-01-20 to 2012-02-15, data date 2012-02-01, A marks actual dates.

## Calendars

- Standard 5 Day Workweek w/ Basic Holidays: Mon-Fri 08:00-12:00, 13:00-17:00; Sat-Sun off. Exceptions (off unless hours are given): 2012-01-30, 2012-02-06.

## Schedule

| ID | Activity | Type | Duration | Start | Finish | Predecessors | Complete | Remaining | Planned start | Planned finish | Total float |
| --- | --- | --- | --- | --- | --- | --- | --- | --- | --- | --- | --- |
| A1000 | Excavate for new drainage line |  | 2d | 2012-01-20 A | 2012-01-23 A |  | 100% |  |  |  |  |
| A1010 | Prepare for and lay bedding material |  | 1d | 2012-01-24 A | 2012-01-24 A | A1000 | 100% |  |  |  |  |
| A1020 | Lay New Pipe |  | 3d | 2012-01-25 A | 2012-01-27 A | A1010 | 100% |  |  |  |  |
| A1030 | Pipe Backfilling | level of effort | 3d | 2012-01-31 A | 2012-02-08 | A1030A SS, A1030C FF |  | 5d | 2012-01-31 | 2012-02-02 | 0d |
| A1030A | Pipe Backfilling - Stage 1 |  | 1d | 2012-01-31 A | 2012-01-31 A | A1020 | 100% |  | 2012-02-01 | 2012-02-01 |  |
| A1030B | Works Suspended |  | 3d | 2012-02-01 | 2012-02-03 | A1030A |  |  |  |  | 0d |
| A1030C | Pipe Backfilling - Stage 2 |  | 2d | 2012-02-07 | 2012-02-08 | A1030B |  |  |  |  | 0d |
| A1040 | Construct new pavement layers |  | 2d | 2012-02-09 | 2012-02-10 | A1030C |  |  |  |  | 0d |
| A1050 | Testing |  | 1d | 2012-02-13 | 2012-02-13 | A1040 |  |  |  |  | 0d |
| A1060 | Surfacing |  | 2d | 2012-02-14 | 2012-02-15 | A1050 |  |  |  |  | 0d |
